# HFT PLAN A

Schedule from MS Project, 2009-08-03 to 2013-12-02, A marks actual dates.

## Calendars

- Standard: Mon-Fri 08:00-12:00, 13:00-17:00; Sat-Sun off.

## Resources

| Resource |
| --- |
| 6a |
| 7 |
| 1a |
| 2a |
| 3a |
| 8 |
| 9 |
| 10 |
| 11 |
| 12 |
| 13 |
| 14 |
| 15 |
| 16 |
| 17 |
| 19 |
| 22 |
| 23 |
| 24 |
| 25 |
| 27 |
| 28 |
| 30 |
| 31 |
| 33 |
| 34 |
| 35 |
| 36 |
| 37 |
| 38 |

## Schedule

| ID | WBS | Task | Type | Duration | Start | Finish | Predecessors | Total slack | Free slack | Constraint | Deadline |
| --- | --- | --- | --- | --- | --- | --- | --- | --- | --- | --- | --- |
| 1 | 1.2.1 | **Pixel Mechanics** |  | 951d | 2009-08-03 | 2013-03-25 |  | 0d |  |  |  |
| 2 | 1.2.1.1 | **Module Support (Sector)** |  | 302d | 2011-10-03 | 2012-11-27 |  | 0d |  |  |  |
| 3 | 1.2.1.1.1 | Sector Mechanical Prototypes (EngRun) |  | 24d | 2011-10-03 | 2011-11-03 |  | 135d | 0d | start no earlier than 2011-10-03 |  |
| 4 | 1.2.1.1.2 | Production Sectors (Batch 1) |  | 42d | 2012-10-01 | 2012-11-27 | 3 | 0d |  | start no earlier than 2012-10-01 |  |
| 5 | 1.2.1.2 | **D-Tube and Kinematic Mounts** |  | 223d | 2009-08-03 | 2010-06-09 |  | 0d |  |  |  |
| 6 | 1.2.1.2.1 | **Prototype D-Tube** |  | 80d | 2010-01-26 | 2010-05-17 |  | 497d |  |  |  |
| 7 | 1.2.1.2.1 | Design |  | 23d | 2010-01-26 | 2010-02-25 | 25 | 497d | 0d |  |  |
| 8 | 1.2.1.2.1 | Fabricate |  | 57d | 2010-02-26 | 2010-05-17 | 7 | 497d | 0d |  |  |
| 9 | 1.2.1.2.2 | **Prototype Kinematic Mounts** |  | 74d | 2010-02-26 | 2010-06-09 |  | 497d |  |  |  |
| 10 | 1.2.1.2.2 | Design |  | 15d | 2010-02-26 | 2010-03-18 | 7 | 539d | 42d |  |  |
| 11 | 1.2.1.2.2 | Fabricate |  | 17d | 2010-05-18 | 2010-06-09 | 10, 8 | 497d | 0d |  |  |
| 12 | 1.2.1.2.3 | **Production D-Tube and Kinematic Mounts** |  | 33d | 2009-08-03 | 2009-09-16 |  | 0d |  |  |  |
| 13 | 1.2.1.2.3 | Fabricate |  | 10d | 2009-08-03 | 2009-08-14 |  | 0d |  |  |  |
| 14 | 1.2.1.2.3 | Assemble |  | 23d | 2009-08-17 | 2009-09-16 | 13 | 0d |  |  |  |
| 15 | 1.2.1.3 | **Insertion Mechanism and Internal Service Supports** |  | 865d | 2009-12-01 | 2013-03-25 |  | 14d |  |  |  |
| 16 | 1.2.1.3.1 | Thermal Prototype Complete | milestone | 0d | 2009-12-18 | 2009-12-18 |  | 1d |  | start no earlier than 2009-12-18 | 2009-12-18 |
| 17 | 1.2.1.3.2 | **Insertion Test Bed** |  | 120d | 2009-12-01 | 2010-05-17 |  | 497d |  |  |  |
| 18 | 1.2.1.3.2 | Design |  | 20d | 2009-12-01 | 2009-12-28 |  | 497d | 0d | start no earlier than 2009-12-01 |  |
| 19 | 1.2.1.3.2 | Fabricate |  | 10d | 2009-12-29 | 2010-01-11 | 18 | 514d | 0d |  |  |
| 20 | 1.2.1.3.2 | Assemble |  | 40d | 2010-01-12 | 2010-03-08 | 19 | 514d | 0d |  |  |
| 21 | 1.2.1.3.2 | Design Iteration |  | 20d | 2010-03-09 | 2010-04-05 | 20, 28 | 514d | 0d |  |  |
| 22 | 1.2.1.3.2 | Modify |  | 10d | 2010-04-06 | 2010-04-19 | 21 | 514d | 0d |  |  |
| 23 | 1.2.1.3.2 | Assemble/Test |  | 20d | 2010-04-20 | 2010-05-17 | 22 | 514d | 17d |  |  |
| 24 | 1.2.1.3.3 | **Prototype Insertion Mechanism** |  | 244d | 2009-12-29 | 2010-12-03 |  | 497d |  |  |  |
| 25 | 1.2.1.3.3 | Design |  | 20d | 2009-12-29 | 2010-01-25 | 18 | 497d | 0d |  |  |
| 26 | 1.2.1.3.3 | Fabricate |  | 10d | 2010-01-26 | 2010-02-08 | 25 | 514d | 0d |  |  |
| 27 | 1.2.1.3.3 | Assemble |  | 10d | 2010-02-09 | 2010-02-22 | 26 | 514d | 0d |  |  |
| 28 | 1.2.1.3.3 | Test of Prototype |  | 10d | 2010-02-23 | 2010-03-08 | 27 | 514d | 0d |  |  |
| 29 | 1.2.1.3.3 | Design Iteration |  | 20d | 2010-06-10 | 2010-07-07 | 11, 23 | 497d | 82d |  |  |
| 30 | 1.2.1.3.3 | Fabrication and Assembly of EngRun Mechanism |  | 25d | 2010-11-01 | 2010-12-03 | 29 | 557d |  | start no earlier than 2010-11-01 |  |

| ID | WBS | Task | Type | Duration | Start | Finish | Predecessors | Complete | Remaining | Total slack | Free slack | Constraint | Resources | Work |
| --- | --- | --- | --- | --- | --- | --- | --- | --- | --- | --- | --- | --- | --- | --- |
| 31 | 1.2.1.3.4 | **Production Insertion Mechanism** |  | 44d | 2013-01-23 | 2013-03-25 |  |  |  | 0d |  |  |  |  |
| 32 | 1.2.1.3.4 | Production Insertion Mechanism Final |  | 22d | 2013-01-23 | 2013-02-21 | 30, 46 |  |  | 0d |  |  |  |  |
| 33 | 1.2.1.3.4 | Production Insertion Mechanism Spare |  | 22d | 2013-02-22 | 2013-03-25 | 32 |  |  | 0d |  |  |  |  |
| 34 | 1.2.1.3.5 | **Prototype Patch Panel Bulkhead** |  | 38d | 2011-01-10 | 2011-03-02 |  |  |  | 365d |  |  |  |  |
| 35 | 1.2.1.3.5 | Design |  | 16d | 2011-01-10 | 2011-01-31 | 29 |  |  | 365d | 0d | start no earlier than 2011-01-10 |  |  |
| 36 | 1.2.1.3.5 | Fabricate/Assemble |  | 22d | 2011-02-01 | 2011-03-02 | 35 |  |  | 365d | 355d |  |  |  |
| 37 | 1.2.1.3.6 | **Production Patch Panel Bulkhead** |  | 45d | 2012-10-01 | 2012-11-30 |  |  |  | 140d |  |  |  |  |
| 38 | 1.2.1.3.6 | Detector 1 |  | 45d | 2012-10-01 | 2012-11-30 | 36 |  |  | 140d | 75d | start no earlier than 2012-10-01 |  |  |
| 39 | 1.2.3 | **Detector Assembly** |  | 376d | 2011-11-04 | 2013-04-12 |  |  |  | 65d |  |  |  |  |
| 40 | 1.2.3.1 | **Sector Assembly** |  | 298d | 2011-11-04 | 2012-12-25 |  |  |  | 0d |  |  |  |  |
| 41 | 1.2.3.1.1 | EngRun Sector Assemblies |  | 22d | 2011-11-04 | 2011-12-05 | 3 |  |  | 135d | 0d |  |  |  |
| 42 | 1.2.3.1.2 | Production Sector Assemblies Batch 1 |  | 20d | 2012-11-28 | 2012-12-25 | 4 |  |  | 0d |  |  |  |  |
| 43 | 1.2.3.2 | D-Tube Assembly and Survey Tool |  | 32d | 2011-12-06 | 2012-01-18 | 41 |  |  | 135d | 125d |  |  |  |
| 44 | 1.2.3.3 | **Sector Mount And Survey** |  | 296d | 2011-12-06 | 2013-01-22 |  |  |  | 0d |  |  |  |  |
| 45 | 1.2.3.3 | EngRun Sector Batch |  | 15d | 2011-12-06 | 2011-12-26 | 41 |  |  | 152d | 142d |  |  |  |
| 46 | 1.2.3.3 | Production Sector Batch 1 |  | 20d | 2012-12-26 | 2013-01-22 | 42 |  |  | 0d |  |  |  |  |
| 47 | 1.2.3.4.2 | **Half Detector Assembly** |  | 197d | 2012-07-12 | 2013-04-12 |  |  |  | 10d |  |  |  |  |
| 48 | 1.2.3.4.2 | Engineering Run |  | 30d | 2012-07-12 | 2012-08-22 | 45, 36, 43, 79SS+5d |  |  | 10d |  |  |  |  |
| 49 | 1.2.3.4.2 | Final Detector |  | 20d | 2013-03-18 | 2013-04-12 | 38, 32, 90SS+20d, 46 |  |  | 65d | 13d |  |  |  |
| 50 | 1.2.2 | **Pixel Electronics** |  | 1130d | 2009-08-03 A | 2013-12-02 |  |  | 1130d | 0d |  |  |  | 10912h |
| 51 | 3.1 | RDO development - individual sensor RDO | milestone | 0d | 2009-08-03 A | 2009-08-03 A |  | 100% |  |  |  | as late as possible | 6a |  |
| 52 | 3.2 | RDO development - ladder RDO |  | 100d | 2009-08-03 | 2009-12-18 |  |  |  | 81d | 0d |  | 7 | 800h |
| 53 | 3.3 | cable prototype- infrastructure |  | 110d | 2009-10-12 | 2010-03-12 | 52SS+50d |  |  | 356d | 0d |  | 1a | 880h |
| 54 | 3.4 | cable prototype - FR4/Cu |  | 60d | 2010-03-15 | 2010-06-04 | 53 |  |  | 356d | 0d |  | 2a | 480h |
| 55 | 3.5 | Ph-1 cable prototype - Kapton/Cu |  | 80d | 2010-06-07 | 2010-09-24 | 54 |  |  | 356d | 265d |  | 3a | 640h |
| 56 | 3.6 | RDO production (prototype (test)) |  | 150d | 2011-10-03 | 2012-04-27 | 55 |  |  | 93d |  | start no earlier than 2011-10-03 | 8 | 1200h |
| 57 | 3.7 | RDO production final system |  | 150d | 2012-10-04 | 2013-05-01 | 52FS+60d, 80SS+20d |  |  | 52d | 0d | start no earlier than 2012-06-01 | 9 | 1200h |
| 58 | 3.8 | Probe testing station development |  | 40d | 2009-08-03 | 2009-09-25 |  |  |  | 121d | 105d |  | 10 | 320h |
| 59 | 3.9 | Probe test Ph-2 development |  | 20d | 2010-02-22 | 2010-03-19 | 58 |  |  | 16d | 0d | start no earlier than 2010-02-22 | 11 | 160h |
| 60 | 3.10 | Ph-2 sensor order |  | 1d | 2009-08-03 | 2009-08-03 |  |  |  | 134d | 0d |  | 12 | 8h |
| 61 | 3.11 | Ph-2 sensor receive |  | 1d | 2009-10-06 | 2009-10-06 | 60FS+45d |  |  | 134d | 118d |  | 13 | 8h |
| 62 | 3.12 | PH-2 Testing and Validation |  | 40d | 2010-03-22 | 2010-05-14 | 52, 59, 61 |  |  | 16d | 0d |  | 14 | 320h |
| 63 | 3.13 | PH-2 dicing and thinning |  | 15d | 2010-05-17 | 2010-06-04 | 62 |  |  | 16d | 0d |  | 15 | 120h |
| 64 | 3.14 | PH-1/2 Probe Testing (prototype) |  | 20d | 2010-06-07 | 2010-07-02 | 63 |  |  | 16d | 0d |  | 16 | 160h |
| 65 | 3.15 | PXL Probe testing prototype |  | 40d | 2010-07-05 | 2010-08-27 | 64 |  |  | 16d | 0d |  |  |  |
| 66 | 3.16 | PXL Cable prototype - Kapton/Cu |  | 37d | 2012-02-07 | 2012-03-28 | 53, 55, 84FS-60d |  |  | 0d |  | start no earlier than 2011-08-01 | 22 | 296h |
| 67 | 3.17 | PXL Cable prototype - Kapton/Al |  | 50d | 2012-03-29 | 2012-06-06 | 66 |  |  | 0d |  |  | 23 | 400h |
| 68 | 3.18 | PXL Cable production - Kapton/Al |  | 45d | 2012-10-01 | 2012-11-30 | 67 |  |  | 55d |  | start no earlier than 2012-10-01 | 24 | 360h |
| 69 | 3.19 | PXL final sensor prototype 1 order | milestone | 0d | 2010-02-04 | 2010-02-04 |  |  |  | 0d |  | must start on 2010-02-04 | 25 |  |
| 70 | 3.20 | PXL Final sensor prototype 1 receive | milestone | 0d | 2010-04-07 | 2010-04-07 | 69FS+45d |  |  | 118d | 102d |  |  |  |
| 71 | 3.21 | milestone (Receive Prototype Sensors | milestone | 0d | 2010-06-01 | 2010-06-01 |  |  |  | 0d |  | must start on 2010-06-01 |  |  |
| 72 | 3.22 | PXL prototype 1 test |  | 100d | 2010-08-30 | 2011-01-14 | 65, 70 |  |  | 16d | 0d |  | 27 | 800h |
| 73 | 3.23 | respin sensor design |  | 100d | 2011-01-17 | 2011-06-03 | 72 |  |  | 16d | 0d |  |  |  |
| 74 | 3.24 | PXL final sensor prototype 2 order | milestone | 0d | 2011-06-03 | 2011-06-03 | 73 |  |  | 16d | 0d |  | 28 |  |
| 75 | 3.25 | PXL Final sensor prototype 2 receive | milestone | 0d | 2011-08-05 | 2011-08-05 | 74FS+45d |  |  | 16d | 0d |  |  |  |
| 76 | 3.26 | PXL Final Sensor prototype 2 test |  | 70d | 2011-08-08 | 2011-11-11 | 52, 75 |  |  | 16d | 0d |  | 30 | 560h |
| 77 | 3.27 | respin sensor design |  | 60d | 2011-11-14 | 2012-02-03 | 76 |  |  | 16d | 0d |  |  |  |
| 78 | 3.28 | PXL Prototype Ladder Production |  | 60d | 2012-06-07 | 2012-08-29 | 67, 76 |  |  | 0d |  |  |  |  |
| 79 | 3.29 | PXL Prototype Ladder Testing |  | 45d | 2012-07-05 | 2012-09-05 | 78SS+20d |  |  | 0d |  |  |  |  |
| 80 | 3.30 | PXL Prototype Detector Testing |  | 90d | 2012-09-06 | 2013-01-09 | 56, 48, 79, 78 |  |  | 0d |  |  |  |  |
| 81 | 3.31 | Install PXL Prototype Detector | milestone | 0d | 2013-01-09 | 2013-01-09 | 80 |  |  | 0d |  | start no earlier than 2013-01-07 |  |  |
| 82 | 3.32 | PXL final sensor order (1st production) | milestone | 0d | 2012-02-03 | 2012-02-03 | 75, 77 |  |  | 16d | 0d |  | 31 |  |
| 83 | 3.33 | PXL final sensor receive (1st production) | milestone | 0d | 2012-04-06 | 2012-04-06 | 82FS+45d |  |  | 16d |  |  |  |  |
| 84 | 3.34 | milestone (Receive Final Sensors) | milestone | 0d | 2012-05-01 | 2012-05-01 | 83 |  |  | 0d |  | start no earlier than 2012-05-01 |  |  |
| 85 | 3.35 | PXL Testing and Validation |  | 20d | 2012-05-01 | 2012-05-28 | 84 |  |  | 89d |  |  | 33 | 160h |
| 86 | 3.36 | PXL final sensor order (2nd production) | milestone | 0d | 2012-10-01 | 2012-10-01 | 85 |  |  | 0d |  | must start on 2012-10-01 |  |  |
| 87 | 3.37 | PXL final sensor receive (2nd production) | milestone | 0d | 2012-11-30 | 2012-11-30 | 86FS+45d |  |  | 0d |  |  |  |  |
| 88 | 3.38 | PXL production dicing and thinning |  | 15d | 2012-12-03 | 2012-12-21 | 83, 87 |  |  | 0d |  |  | 34 | 120h |
| 89 | 3.39 | PXL Probe Testing |  | 40d | 2012-12-24 | 2013-02-15 | 64, 88 |  |  | 0d |  |  | 35 | 320h |
| 90 | 3.40 | PXL Ladder production |  | 100d | 2013-02-18 | 2013-07-05 | 68, 89 |  |  | 0d |  |  | 36 | 800h |
| 91 | 3.41 | sector/detector testing |  | 100d | 2013-05-02 | 2013-09-18 | 57, 49, 90SS+50d |  |  | 52d |  |  | 38 | 800h |
| 92 | 3.42 | install PXL detector | milestone | 0d | 2013-12-02 | 2013-12-02 | 91 |  |  | 0d |  | start no earlier than 2013-12-02 |  |  |

Notes:
- 51: 1.2.2.5.1 / line 226 / $6,000 / all other in FY09
- 52: all contributed labor / 0 cost
- 53: 1.2.2.3.1 / $38,652 inc cont
- 54: 1.2.2.3.2 / $35,660 / 1 iteration in scope
- 55: 1.2.2.3.3 / $39,852 / 2 iterations in scope
- 56: 1.2.2.5.1 / line 239-246, 267-269, 278-280 / $175,106
- 57: 1.2.2.5.1 / line 233-238, 249-252, 259-266, 272-277, 283-286 / $285,221
- 58: 1.2.2.1.2 / line 46, 56, 58-60 / $52,486
- 59: 1.2.2.1.2 / line 49-50 / $9485
- 61: 1.2.2.1.2 / $54,650 base / $80,050 cont
- 62: 1.2.2.1.1 / lines 23-25, 29-36 / $28,930
- 63: 1.2.2.1.2 / line 42 / $5516
- 64: 1.2.2.1.2 / line 61 / 0
- 66: 1.2.2.3.5 / line 171-174 / $23,291
- 67: 1.2.2.3.5 / line 175-182 / $51,314 / contains 2 iterations (prototype and final)
- 68: 1.2.2.6 / line 308-309 / $244,004
- 69: 1.2.2.2.1 / line 69-70 / $155,000
- 72: 1.2.2.2.1 / line 80-87 / $25,276
- 74: 1.2.2.2.1 / line 71-72 / $155,000
- 76: 1.2.2.2.1 / line 90-103 / $66,466
- 82: 1.2.2.2.2 / line 106-108 / $281,124
- 88: 1.2.2.2.2 / line 109-110 / $34,660
- 89: 1.2.2.2.2 / line 113-123 / $86,491
- 90: 1.2.2.6 / line 293, 295-297, 300, 303-309, 311-316 / $579,319 / of which 244,004 is Al conductor cables
- 91: 1.2.2.6 / line 306, 313 / $34,214

| ID | WBS | Task | Type | Duration | Start | Finish | Predecessors | Total slack | Free slack | Constraint |
| --- | --- | --- | --- | --- | --- | --- | --- | --- | --- | --- |
| 93 | 1.5 | **Integration and Global Supports** |  | 730d | 2011-01-03 | 2013-10-18 |  | -98d | 0d |  |
| 94 | 1.5.1 | **Mechanics** |  | 450d | 2011-01-03 | 2012-09-21 |  | -98d | 0d |  |
| 95 | 1.5.1.1 | **Inner Detector Support (IDS)** |  | 165d | 2011-01-10 | 2011-08-26 |  | -103d | 0d |  |
| 96 | 1.5.1.1.2 | **East Support Cylinder (ESC)** |  | 135d | 2011-01-10 | 2011-07-15 |  | -103d | 0d |  |
| 97 | 1.5.1.1.2 | Order Material/Tooling |  | 5d | 2011-01-10 | 2011-01-14 |  | -103d | 0d | start no earlier than 2011-01-10 |
| 98 | 1.5.1.1.2 | Fabricate Parts |  | 60d | 2011-03-28 | 2011-06-17 | 97FS+10w | -103d | 0d |  |
| 99 | 1.5.1.1.2 | Assemble |  | 20d | 2011-06-20 | 2011-07-15 | 98 | -93d | 0d |  |
| 100 | 1.5.1.1.3 | **Outer Support Cylinder (OSC)** |  | 165d | 2011-01-10 | 2011-08-26 |  | -103d | 0d |  |
| 101 | 1.5.1.1.3 | Order Material/Tooling |  | 5d | 2011-01-10 | 2011-01-14 |  | -43d | 0d | start no earlier than 2011-01-10 |
| 102 | 1.5.1.1.3 | Fabricate Parts |  | 30d | 2011-06-20 | 2011-07-29 | 101FS+10w, 98 | -103d | 0d |  |
| 103 | 1.5.1.1.3 | Assemble |  | 20d | 2011-08-01 | 2011-08-26 | 102, 99 | -103d | 0d |  |
| 104 | 1.5.1.1.4 | **E-Field Shroud (EFS)** |  | 160d | 2011-01-10 | 2011-08-19 |  | 27d |  |  |
| 105 | 1.5.1.1.4 | Order Material |  | 5d | 2011-01-10 | 2011-01-14 |  | 117d | 90d | start no earlier than 2011-01-10 |
| 106 | 1.5.1.1.4 | Fabricate Parts |  | 15d | 2011-08-01 | 2011-08-19 | 105FS+10w, 102 | 27d |  |  |
| 107 | 4.1.2 | IDS Shipped to BNL | milestone | 0d | 2011-09-09 | 2011-09-09 | 103FS+10d | 0d |  |  |
| 108 | 1.5.1.2 | **Middle Support Cylinder (MSC)** |  | 450d | 2011-01-03 | 2012-09-21 |  | 12d |  |  |
| 109 | 1.5.1.2.1 | **Pixel Insertion Tube** |  | 210d | 2011-01-03 | 2011-10-21 |  | -88d | 0d |  |
| 110 | 1.5.1.2.1 | Order Material/Tooling |  | 5d | 2011-01-03 | 2011-01-07 |  | 12d |  | start no earlier than 2011-01-03 |
| 111 | 1.5.1.2.1 | Fabricate Parts |  | 30d | 2011-08-29 | 2011-10-07 | 110FS+10w, 103 | -103d | 0d |  |
| 112 | 1.5.1.2.1 | Assemble |  | 10d | 2011-10-10 | 2011-10-21 | 111 | -88d | 0d |  |
| 113 | 1.5.1.2.2 | **Bulkhead Extension** |  | 225d | 2011-01-03 | 2011-11-11 |  | -93d | 0d |  |
| 114 | 1.5.1.2.2 | Order Material/Tooling |  | 5d | 2011-01-03 | 2011-01-07 |  | 42d |  | start no earlier than 2011-01-03 |
| 115 | 1.5.1.2.2 | Fabricate Parts |  | 15d | 2011-10-10 | 2011-10-28 | 114FS+10w, 111 | -103d | 0d |  |
| 116 | 1.5.1.2.2 | Assemble |  | 10d | 2011-10-31 | 2011-11-11 | 115, 112 | -93d | 0d |  |

| ID | WBS | Task | Type | Duration | Start | Finish | Predecessors | Total slack | Free slack | Constraint |
| --- | --- | --- | --- | --- | --- | --- | --- | --- | --- | --- |
| 117 | 1.5.1.2.3 | **Transition Plate** |  | 22d | 2011-01-03 | 2011-02-01 |  | 130d |  |  |
| 118 | 1.5.1.2.3 | Order Material |  | 5d | 2011-01-03 | 2011-01-07 |  | 130d | 0d | start no earlier than 2011-01-03 |
| 119 | 1.5.1.2.3 | Fabricate Parts |  | 15d | 2011-01-12 | 2011-02-01 | 118FS+2d | 130d | 233d |  |
| 120 | 1.5.1.2.4 | **Pixel Support Tube** |  | 255d | 2011-01-03 | 2011-12-23 |  | -103d | 0d |  |
| 121 | 1.5.1.2.4 | Order Material/Tooling |  | 5d | 2011-01-03 | 2011-01-07 |  | 57d | 160d | start no earlier than 2011-01-03 |
| 122 | 1.5.1.2.4 | Fabricate Parts |  | 20d | 2011-10-31 | 2011-11-25 | 121FS+10w, 115 | -103d | 0d |  |
| 123 | 1.5.1.2.4 | Assemble |  | 20d | 2011-11-28 | 2011-12-23 | 122, 116 | -103d | 0d |  |
| 124 | 4.1.3.5 | MSC Shipped to BNL | milestone | 0d | 2012-01-06 | 2012-01-06 | 123FS+10d | 0d |  |  |
| 125 | 1.5.1.2 | **MSC COPY** |  | 125d | 2012-04-02 | 2012-09-21 |  | 35d |  |  |
| 126 | 1.5.1.2.1 | **Pixel Insertion Tube** |  | 85d | 2012-04-02 | 2012-07-27 |  | 35d |  |  |
| 127 | 1.5.1.2.1 | Order Material/Tooling |  | 5d | 2012-04-02 | 2012-04-06 |  | 35d | 0d | start no earlier than 2012-04-02 |
| 128 | 1.5.1.2.1 | Fabricate Parts |  | 20d | 2012-06-18 | 2012-07-13 | 127FS+10w | 35d | 0d |  |
| 129 | 1.5.1.2.1 | Assemble |  | 10d | 2012-07-16 | 2012-07-27 | 128 | 50d | 0d |  |
| 130 | 1.5.1.2.2 | **Bulkhead Extension** |  | 90d | 2012-04-02 | 2012-08-03 |  | 50d |  |  |
| 131 | 1.5.1.2.2 | Order Material/Tooling |  | 5d | 2012-04-02 | 2012-04-06 |  | 55d | 20d | start no earlier than 2012-04-02 |
| 132 | 1.5.1.2.2 | Fabricate Parts |  | 10d | 2012-07-16 | 2012-07-27 | 128, 131FS+10w | 35d | 0d |  |
| 133 | 1.5.1.2.2 | Assemble |  | 5d | 2012-07-30 | 2012-08-03 | 129, 132 | 50d | 15d |  |
| 134 | 1.5.1.2.3 | **Transition Plate** |  | 22d | 2012-04-02 | 2012-05-01 |  | 138d |  |  |
| 135 | 1.5.1.2.3 | Order Material |  | 5d | 2012-04-02 | 2012-04-06 |  | 138d | 0d | start no earlier than 2012-04-02 |
| 136 | 1.5.1.2.3 | Fabricate Parts |  | 15d | 2012-04-11 | 2012-05-01 | 135FS+2d | 138d | 103d |  |
| 137 | 1.5.1.2.4 | **Pixel Support Tube** |  | 125d | 2012-04-02 | 2012-09-21 |  | 35d |  |  |
| 138 | 1.5.1.2.4 | Order Material/Tooling |  | 5d | 2012-04-02 | 2012-04-06 |  | 65d | 30d | start no earlier than 2012-04-02 |
| 139 | 1.5.1.2.4 | Fabricate Parts |  | 20d | 2012-07-30 | 2012-08-24 | 132, 138FS+10w | 35d | 0d |  |
| 140 | 1.5.1.2.4 | Assemble |  | 20d | 2012-08-27 | 2012-09-21 | 133, 139 | 35d | 0d |  |
| 141 | 4.2 | IST Integration START | milestone | 0d | 2013-01-07 | 2013-01-07 | 144 | 0d |  | must start on 2013-01-07 |

| ID | WBS | Task | Type | Duration | Start | Finish | Predecessors | Total slack | Free slack | Constraint |
| --- | --- | --- | --- | --- | --- | --- | --- | --- | --- | --- |
| 142 | 1.5.3 | **Assembly** |  | 465d | 2011-12-26 | 2013-10-04 |  | -103d | 0d |  |
| 143 | 1.5.3.1 | MSC Assembly |  | 40d | 2011-12-26 | 2012-02-17 | 123, 119 | -103d | 0d |  |
| 144 | 1.5.3.1 | MSC Assembly (Copy) |  | 40d | 2012-09-24 | 2012-11-16 | 140, 136 | 35d |  |  |
| 145 | 1.5.3.2 | IDS Assembly Engineering Run |  | 15d | 2012-02-20 | 2012-03-09 | 103, 143, 106 | -103d | 0d |  |
| 146 | 1.5.3.2 | IDS Dis-Assembly |  | 15d | 2013-06-03 | 2013-06-21 | 154 | 0d |  |  |
| 147 | 1.5.3.2 | IDS Assembly Final Run |  | 15d | 2013-09-16 | 2013-10-04 | 146FS+60d, 144 | 0d |  |  |
| 148 | 1.5.4 | **Integration Infrastructure** |  | 60d | 2012-07-09 | 2012-09-28 |  | 0d |  |  |
| 149 | 1.5.4.3 | **Hall Modifications and Safety** |  | 60d | 2012-07-09 | 2012-09-28 |  | 0d |  |  |
| 150 | 1.5.4.3.2 | External Clean Tent |  | 60d | 2012-07-09 | 2012-09-28 |  | 0d |  | must finish on 2012-09-28 |
| 151 | 1.5.5 | **Installation** |  | 513d | 2011-11-01 | 2013-10-18 |  | -10d | 0d |  |
| 152 | 4.5.1 | Install Run 12 (effort) |  | 10d | 2012-03-12 | 2012-03-23 | 145 | -103d | 0d |  |
| 153 | 4.5.2 | Install Run 12 Milestone | milestone | 0d | 2011-11-01 | 2011-11-01 | 152 | -103d | 0d | must finish on 2011-11-01 |
| 154 | 4.5.3 | Remove Run 13 |  | 20d | 2013-05-06 | 2013-05-31 |  | 0d |  | start no earlier than 2013-05-06 |
| 155 | 4.5.4 | Install Run 14 |  | 10d | 2013-10-07 | 2013-10-18 | 154, 147 | 0d |  |  |
